# Project ISNAGRO

Schedule from MS Project, 2026-06-01 to 2026-12-04.

## Calendars

- Estándar: Mon-Fri 09:00-13:00, 15:00-19:00; Sat-Sun off.

## Schedule

| ID | Task | Duration | Start | Finish | Predecessors | Total slack |
| --- | --- | --- | --- | --- | --- | --- |
| 1 | Inicio del proyecto y planificación Scrum | 1.17w | 2026-06-01 | 2026-06-08 |  | 0d |
| 2 | Diagnóstico organizacional y madurez BI | 3w | 2026-06-08 | 2026-06-29 | 1 | 0d |
| 3 | Identificación de fuentes de datos | 2w | 2026-06-29 | 2026-07-13 | 2 | 0d |
| 4 | Diseño arquitectura del modelo BI | 3.17w | 2026-07-13 | 2026-08-04 | 3 | 0d |
| 5 | Diseño procesos ETL | 3w | 2026-08-04 | 2026-08-25 | 4 | 0d |
| 6 | Construcción Data Warehouse / Data Mart | 4.17w | 2026-08-25 | 2026-09-23 | 5 | 0d |
| 7 | Definición indicadores financieros | 2w | 2026-08-04 | 2026-08-18 | 4 | 25.85d |
| 8 | Desarrollo dashboards financieros | 3.17w | 2026-09-23 | 2026-10-15 | 6, 7 | 0d |
| 9 | Pruebas y validación del modelo | 2w | 2026-10-15 | 2026-10-29 | 8 | 0d |
| 10 | Ajustes y mejora iterativa | 2w | 2026-10-29 | 2026-11-12 | 9 | 0d |
| 11 | Implementación final del modelo | 2w | 2026-11-12 | 2026-11-26 | 10 | 0d |
| 12 | Documentación y cierre del proyecto | 1.17w | 2026-11-26 | 2026-12-04 | 11 | 0d |
